# House

How a schedule from MS Project changed from version to version. A marks actual dates.

## Version 1 (saved 2008-01-22, file House.mpp)

| ID | WBS | Task | Duration | Start | Finish | Predecessors | Total float | Constraint |
| --- | --- | --- | --- | --- | --- | --- | --- | --- |
| 1 |  | Conduct Site Survey | 1d | 2011-06-10 08:00 | 2011-06-10 17:00 |  | 0d |  |
| 2 |  | Develop Blueprints | 2w | 2011-06-13 08:00 | 2011-06-24 17:00 | 1 | 0d |  |
| 3 |  | Draft Proposal | 3d | 2011-06-27 08:00 | 2011-06-29 17:00 | 2 | 0d |  |
| 4 |  | Request Bids | 1w | 2011-06-30 08:00 | 2011-07-06 17:00 | 3 | 6d |  |
| 5 |  | Request Building Permits | 1d | 2011-07-07 08:00 | 2011-07-07 17:00 | 4 | 6d |  |
| 6 |  | Obtain Building Permits | 1w | 2011-07-08 08:00 | 2011-07-14 17:00 | 5 | 97.5d |  |
| 7 |  | Obtain Bids | 1w | 2011-07-18 08:00 | 2011-07-22 17:00 | 6FS+1d | 97.5d |  |
| 8 |  | Select Subcontractors | 1w | 2011-07-29 08:00 | 2011-08-04 17:00 | 7 | 93.5d | start no earlier than 2011-07-29 08:00 |
| 9 |  | Complete Planning Phase | 0d | 2011-08-04 17:00 | 2011-08-04 17:00 | 8 | 93.5d |  |
| 10 | 10 | **Build Structure** | 40.5d | 2011-08-09 08:00 | 2011-10-04 12:00 |  | 0d |  |
| 11 | 10.1 | **Build Foundation** | 6.5d | 2011-08-09 08:00 | 2011-08-17 12:00 |  | 0d |  |
| 12 |  | Dig Foundation | 3d | 2011-08-09 08:00 | 2011-08-11 17:00 |  | 0d | start no earlier than 2011-08-09 08:00 |
| 13 |  | Smooth Foundation | 2.5d | 2011-08-12 08:00 | 2011-08-16 12:00 | 12FS-1d | 0d |  |
| 14 |  | Pour Foundation | 1d | 2011-08-16 13:00 | 2011-08-17 12:00 | 13 | 0d |  |
| 15 | 10.2 | **Construct Frame** | 10d | 2011-08-19 13:00 | 2011-09-02 12:00 | 11FS+2d | 0d |  |
| 16 |  | Frame House | 6d | 2011-08-19 13:00 | 2011-08-29 12:00 |  | 0d |  |
| 17 |  | Frame Garage | 3d | 2011-08-30 13:00 | 2011-09-02 12:00 | 16 | 0d |  |
| 18 |  | Install Roof | 1w | 2011-09-02 13:00 | 2011-09-09 12:00 | 15 | 0d |  |
| 19 |  | Install Doors | 3d | 2011-09-09 13:00 | 2011-09-14 12:00 | 18 | 0d |  |
| 20 |  | Install Windows | 4d | 2011-09-16 13:00 | 2011-09-22 12:00 | 19 | 0d |  |
| 21 |  | Install Siding | 1w | 2011-09-22 13:00 | 2011-09-29 12:00 | 20 | 0d |  |
| 22 |  | Build Deck | 3d | 2011-09-29 13:00 | 2011-10-04 12:00 | 21 | 0d |  |
| 23 | 11 | **Build Infrastructure** | 51d | 2011-10-04 13:00 | 2011-12-14 12:00 | 10 | 0d |  |
| 24 |  | Initial Plumbing | 7d | 2011-10-04 13:00 | 2011-10-13 12:00 |  | 0d |  |
| 25 |  | Initial Electricity | 2w | 2011-10-13 13:00 | 2011-10-27 12:00 | 24 | 0d |  |
| 26 |  | Security System | 1d | 2011-10-27 13:00 | 2011-10-28 12:00 | 25 | 0d |  |
| 27 |  | Install Cable | 1d | 2011-10-28 13:00 | 2011-10-31 12:00 | 26 | 0d |  |
| 28 |  | Run Phone Lines | 1d | 2011-10-31 13:00 | 2011-11-01 12:00 | 27 | 0d |  |
| 29 |  | Insulation | 4d | 2011-11-01 13:00 | 2011-11-07 12:00 | 28 | 0d |  |
| 30 |  | Drywall | 4d | 2011-11-07 13:00 | 2011-11-11 12:00 | 29 | 0d |  |
| 31 |  | Painting | 3d | 2011-11-11 13:00 | 2011-11-16 12:00 | 30 | 0d |  |
| 32 |  | Flooring | 1w | 2011-11-18 13:00 | 2011-11-25 12:00 | 31FS+2d | 0d |  |
| 33 |  | Final Plumbing | 3d | 2011-11-25 13:00 | 2011-11-30 12:00 | 32 | 0d |  |
| 34 |  | Final Electric | 3d | 2011-11-30 13:00 | 2011-12-05 12:00 | 33 | 0d |  |
| 35 |  | Cabinets | 2d | 2011-12-05 13:00 | 2011-12-07 12:00 | 34 | 0d |  |
| 36 |  | Wood Trim | 3d | 2011-12-07 13:00 | 2011-12-12 12:00 | 35 | 0d |  |
| 37 |  | Carpeting | 2d | 2011-12-12 13:00 | 2011-12-14 12:00 | 36 | 0d |  |
| 38 |  | Landscape | 1w | 2011-11-21 08:00 | 2011-11-25 17:00 |  | 12.5d | start no earlier than 2011-11-20 08:00 |
| 39 |  | Cement Work | 2d | 2011-11-25 08:00 | 2011-11-28 17:00 |  | 11.5d | start no earlier than 2011-11-25 08:00 |
| 40 | 14 | **Status Meeting** | 125.12d | 2011-06-13 08:00 | 2011-12-05 09:00 |  | 7.38d |  |
| 41 |  | Status Meeting 1 | 1h | 2011-06-13 08:00 | 2011-06-13 09:00 |  | 132.38d | start no earlier than 2011-06-13 08:00 |
| 42 |  | Status Meeting 2 | 1h | 2011-06-20 08:00 | 2011-06-20 09:00 |  | 127.38d | start no earlier than 2011-06-20 08:00 |
| 43 |  | Status Meeting 3 | 1h | 2011-06-27 08:00 | 2011-06-27 09:00 |  | 122.38d | start no earlier than 2011-06-27 08:00 |
| 44 |  | Status Meeting 4 | 1h | 2011-07-04 08:00 | 2011-07-04 09:00 |  | 117.38d | start no earlier than 2011-07-04 08:00 |
| 45 |  | Status Meeting 5 | 1h | 2011-07-11 08:00 | 2011-07-11 09:00 |  | 112.38d | start no earlier than 2011-07-11 08:00 |
| 46 |  | Status Meeting 6 | 1h | 2011-07-18 08:00 | 2011-07-18 09:00 |  | 107.38d | start no earlier than 2011-07-18 08:00 |
| 47 |  | Status Meeting 7 | 1h | 2011-07-25 08:00 | 2011-07-25 09:00 |  | 102.38d | start no earlier than 2011-07-25 08:00 |
| 48 |  | Status Meeting 8 | 1h | 2011-08-01 08:00 | 2011-08-01 09:00 |  | 97.38d | start no earlier than 2011-08-01 08:00 |
| 49 |  | Status Meeting 9 | 1h | 2011-08-08 08:00 | 2011-08-08 09:00 |  | 92.38d | start no earlier than 2011-08-08 08:00 |
| 50 |  | Status Meeting 10 | 1h | 2011-08-15 08:00 | 2011-08-15 09:00 |  | 87.38d | start no earlier than 2011-08-15 08:00 |
| 51 |  | Status Meeting 11 | 1h | 2011-08-22 08:00 | 2011-08-22 09:00 |  | 82.38d | start no earlier than 2011-08-22 08:00 |
| 52 |  | Status Meeting 12 | 1h | 2011-08-29 08:00 | 2011-08-29 09:00 |  | 77.38d | start no earlier than 2011-08-29 08:00 |
| 53 |  | Status Meeting 13 | 1h | 2011-09-05 08:00 | 2011-09-05 09:00 |  | 72.38d | start no earlier than 2011-09-05 08:00 |
| 54 |  | Status Meeting 14 | 1h | 2011-09-12 08:00 | 2011-09-12 09:00 |  | 67.38d | start no earlier than 2011-09-12 08:00 |
| 55 |  | Status Meeting 15 | 1h | 2011-09-19 08:00 | 2011-09-19 09:00 |  | 62.38d | start no earlier than 2011-09-19 08:00 |
| 56 |  | Status Meeting 16 | 1h | 2011-09-26 08:00 | 2011-09-26 09:00 |  | 57.38d | start no earlier than 2011-09-26 08:00 |
| 57 |  | Status Meeting 17 | 1h | 2011-10-03 08:00 | 2011-10-03 09:00 |  | 52.38d | start no earlier than 2011-10-03 08:00 |
| 58 |  | Status Meeting 18 | 1h | 2011-10-10 08:00 | 2011-10-10 09:00 |  | 47.38d | start no earlier than 2011-10-10 08:00 |
| 59 |  | Status Meeting 19 | 1h | 2011-10-17 08:00 | 2011-10-17 09:00 |  | 42.38d | start no earlier than 2011-10-17 08:00 |
| 60 |  | Status Meeting 20 | 1h | 2011-10-24 08:00 | 2011-10-24 09:00 |  | 37.38d | start no earlier than 2011-10-24 08:00 |
| 61 |  | Status Meeting 21 | 1h | 2011-10-31 08:00 | 2011-10-31 09:00 |  | 32.38d | start no earlier than 2011-10-31 08:00 |
| 62 |  | Status Meeting 22 | 1h | 2011-11-07 08:00 | 2011-11-07 09:00 |  | 27.38d | start no earlier than 2011-11-07 08:00 |
| 63 |  | Status Meeting 23 | 1h | 2011-11-14 08:00 | 2011-11-14 09:00 |  | 22.38d | start no earlier than 2011-11-14 08:00 |
| 64 |  | Status Meeting 24 | 1h | 2011-11-21 08:00 | 2011-11-21 09:00 |  | 17.38d | start no earlier than 2011-11-21 08:00 |
| 65 |  | Status Meeting 25 | 1h | 2011-11-28 08:00 | 2011-11-28 09:00 |  | 12.38d | start no earlier than 2011-11-28 08:00 |
| 66 |  | Status Meeting 26 | 1h | 2011-12-05 08:00 | 2011-12-05 09:00 |  | 7.38d | start no earlier than 2011-12-05 08:00 |

## Version 2 (saved 2008-01-23, file Building Project.mpp)

Last finish 2011-12-14 → 2005-12-06 (-2199d).

Removed: 38 Landscape; 39 Cement Work; 40 Status Meeting; 41 Status Meeting 1; 42 Status Meeting 2; 43 Status Meeting 3; 44 Status Meeting 4; 45 Status Meeting 5; 46 Status Meeting 6; 47 Status Meeting 7; 48 Status Meeting 8; 49 Status Meeting 9; 50 Status Meeting 10; 51 Status Meeting 11; 52 Status Meeting 12; 53 Status Meeting 13; 54 Status Meeting 14; 55 Status Meeting 15; 56 Status Meeting 16; 57 Status Meeting 17; 58 Status Meeting 18; 59 Status Meeting 19; 60 Status Meeting 20; 61 Status Meeting 21; 62 Status Meeting 22; 63 Status Meeting 23; 64 Status Meeting 24; 65 Status Meeting 25; 66 Status Meeting 26

Changed:

| ID | Task | Start | Finish | Duration | Total float | Predecessors | Other |
| --- | --- | --- | --- | --- | --- | --- | --- |
| 1 | Conduct Site Survey | 2011-06-10 08:00 → 2005-08-22 (-2118d) | 2011-06-10 17:00 → 2005-08-22 (-2118d) |  | 0d → 41d |  |  |
| 2 | Develop Blueprints | 2011-06-13 08:00 → 2005-08-23 (-2120d) | 2011-06-24 17:00 → 2005-09-05 (-2118d) |  | 0d → 41d |  |  |
| 3 | Draft Proposal | 2011-06-27 08:00 → 2005-09-06 (-2120d) | 2011-06-29 17:00 → 2005-09-08 (-2120d) |  | 0d → 41d |  |  |
| 4 | Request Bids | 2011-06-30 08:00 → 2005-09-09 (-2120d) | 2011-07-06 17:00 → 2005-09-15 (-2120d) |  | 6d → 41d |  |  |
| 5 | Request Permits | 2011-07-07 08:00 → 2005-09-16 (-2120d) | 2011-07-07 17:00 → 2005-09-16 (-2120d) |  | 6d → 41d |  | was named Request Building Permits |
| 6 | Obtain Permits | 2011-07-08 08:00 → 2005-09-19 (-2118d) | 2011-07-14 17:00 → 2005-09-23 (-2120d) |  | 97.5d → 41d |  | was named Obtain Building Permits |
| 7 | Obtain Bids | 2011-07-18 08:00 → 2005-09-27 (-2120d) | 2011-07-22 17:00 → 2005-10-03 (-2118d) |  | 97.5d → 41d |  |  |
| 8 | Select Subcontractors | 2011-07-29 08:00 → 2005-10-04 (-2124d) | 2011-08-04 17:00 → 2005-10-10 (-2124d) |  | 93.5d → 41d |  | constraint start no earlier than 2011-07-29 08:00 → start no earlier than 2002-07-29 |
| 9 | Complete Planning Phase | 2011-08-04 17:00 → 2005-10-10 (-2124d) | 2011-08-04 17:00 → 2005-10-10 (-2124d) |  | 93.5d → 41d |  |  |
| 10 | **Build Structure** | 2011-08-09 08:00 → 2005-08-22 (-2178d) | 2011-10-04 12:00 → 2005-10-19 (-2176d) | 40.5d → 43d |  |  |  |
| 11 | **Build Foundation** | 2011-08-09 08:00 → 2005-08-22 (-2178d) | 2011-08-17 12:00 → 2005-09-02 (-2175d) | 6.5d → 10d |  |  |  |
| 12 | Dig Foundation | 2011-08-09 08:00 → 2005-08-22 (-2178d) | 2011-08-11 17:00 → 2005-08-24 (-2178d) |  |  |  | constraint start no earlier than 2011-08-09 08:00 → none |
| 13 | Smooth Foundation | 2011-08-12 08:00 → 2005-08-25 (-2178d) | 2011-08-16 12:00 → 2005-08-25 (-2182d) | 2.5d → 1d |  |  |  |
| 14 | Pour Foundation | 2011-08-16 13:00 → 2005-08-26 (-2181d) | 2011-08-17 12:00 → 2005-09-02 (-2175d) | 1d → 6d |  |  | resources Laborer; Concrete [4000%] → Laborer |
| 15 | **Construct Frame** | 2011-08-19 13:00 → 2005-09-07 (-2172d) | 2011-09-02 12:00 → 2005-09-20 (-2173d) |  |  |  |  |
| 16 | Frame House | 2011-08-19 13:00 → 2005-09-07 (-2172d) | 2011-08-29 12:00 → 2005-09-14 (-2175d) |  |  |  |  |
| 17 | Frame Garage | 2011-08-30 13:00 → 2005-09-16 (-2174d) | 2011-09-02 12:00 → 2005-09-20 (-2173d) |  |  |  |  |
| 18 | Install Roof | 2011-09-02 13:00 → 2005-09-21 (-2172d) | 2011-09-09 12:00 → 2005-09-27 (-2173d) |  |  |  | resources Roofer [200%]; Roofing Materials → Roofer [200%] |
| 19 | Install Doors | 2011-09-09 13:00 → 2005-09-28 (-2172d) | 2011-09-14 12:00 → 2005-09-29 (-2176d) | 3d → 2d |  |  | resources Laborer [200%]; Doors [1000%] → Laborer [200%] |
| 20 | Install Windows | 2011-09-16 13:00 → 2005-10-03 (-2174d) | 2011-09-22 12:00 → 2005-10-07 (-2176d) | 4d → 5d |  |  | resources Laborer [200%]; Windows [2400%] → Laborer [200%] |
| 21 | Install Siding | 2011-09-22 13:00 → 2005-10-10 (-2173d) | 2011-09-29 12:00 → 2005-10-14 (-2176d) |  |  |  | resources Laborer [200%]; Siding Materials → Laborer [200%] |
| 22 | Build Deck | 2011-09-29 13:00 → 2005-10-17 (-2173d) | 2011-10-04 12:00 → 2005-10-19 (-2176d) |  |  |  |  |
| 23 | **Build Infrastructure** | 2011-10-04 13:00 → 2005-10-20 (-2175d) | 2011-12-14 12:00 → 2005-12-06 (-2199d) | 51d → 34d |  |  |  |
| 24 | Initial Plumbing | 2011-10-04 13:00 → 2005-10-20 (-2175d) | 2011-10-13 12:00 → 2005-10-28 (-2176d) |  |  |  |  |
| 25 | Initial Electricity | 2011-10-13 13:00 → 2005-10-20 (-2184d) | 2011-10-27 12:00 → 2005-11-02 (-2185d) |  |  | 24 → 24SS |  |
| 26 | Security System | 2011-10-27 13:00 → 2005-11-03 (-2184d) | 2011-10-28 12:00 → 2005-11-03 (-2185d) |  |  |  |  |
| 27 | Install Cable | 2011-10-28 13:00 → 2005-11-03 (-2185d) | 2011-10-31 12:00 → 2005-11-03 (-2188d) |  |  | 26 → 26SS |  |
| 28 | Run Phone Lines | 2011-10-31 13:00 → 2005-11-03 (-2188d) | 2011-11-01 12:00 → 2005-11-03 (-2189d) |  |  | 27 → 27SS |  |
| 29 | Insulation | 2011-11-01 13:00 → 2005-11-04 (-2188d) | 2011-11-07 12:00 → 2005-11-07 (-2191d) | 4d → 2d |  |  | resources Laborer [300%]; Insulation [300000%] → Laborer [300%] |
| 30 | Drywall | 2011-11-07 13:00 → 2005-11-08 (-2190d) | 2011-11-11 12:00 → 2005-11-11 (-2191d) |  |  |  | resources Laborer [200%]; Drywall [17000%] → Laborer [200%] |
| 31 | Painting | 2011-11-11 13:00 → 2005-11-14 (-2188d) | 2011-11-16 12:00 → 2005-11-15 (-2192d) | 3d → 2d |  |  | resources Painter [400%]; Paint [2000%] → Painter [400%] |
| 32 | Flooring | 2011-11-18 13:00 → 2005-11-18 (-2191d) | 2011-11-25 12:00 → 2005-11-24 (-2192d) |  |  |  | resources Laborer [200%]; Tile [35000%] → Laborer [200%] |
| 33 | Final Plumbing | 2011-11-25 13:00 → 2005-11-25 (-2191d) | 2011-11-30 12:00 → 2005-11-28 (-2193d) | 3d → 2d |  |  | resources Plumber; Plumbing Supplies → Plumber |
| 34 | Final Electric | 2011-11-30 13:00 → 2005-11-25 (-2196d) | 2011-12-05 12:00 → 2005-11-25 (-2201d) | 3d → 1d |  | 33 → 33SS | resources Electrician [200%]; Light Fixtures → Electrician [200%] |
| 35 | Cabinets | 2011-12-05 13:00 → 2005-11-28 (-2198d) | 2011-12-07 12:00 → 2005-11-29 (-2199d) |  |  |  |  |
| 36 | Wood Trim | 2011-12-07 13:00 → 2005-11-30 (-2198d) | 2011-12-12 12:00 → 2005-12-02 (-2201d) |  |  |  |  |
| 37 | Carpeting | 2011-12-12 13:00 → 2005-12-05 (-2198d) | 2011-12-14 12:00 → 2005-12-06 (-2199d) |  |  |  | resources Carpet Layer [200%]; Carpet [220000%] → Carpet Layer [200%] |

## Version 3 (saved 2008-01-23, file Template Practice.mpp)

Last finish 2005-12-06 → 2012-07-05 (+2403d). Complete tasks 0 → 19.

Changed:

| ID | Task | Start | Finish | Duration | Complete | Total float | Other |
| --- | --- | --- | --- | --- | --- | --- | --- |
| 1 | Conduct Site Survey | 2005-08-22 → 2011-08-22 A (+2191d) | 2005-08-22 → 2011-08-22 A (+2191d) |  | 0% → 100% | 41d → none |  |
| 2 | Develop Blueprints | 2005-08-23 → 2011-08-23 A (+2191d) | 2005-09-05 → 2011-09-05 A (+2191d) |  | 0% → 100% | 41d → none |  |
| 3 | Draft Proposal | 2005-09-06 → 2011-09-06 A (+2191d) | 2005-09-08 → 2011-09-08 A (+2191d) |  | 0% → 100% | 41d → none |  |
| 4 | Request Bids | 2005-09-09 → 2011-09-09 A (+2191d) | 2005-09-15 → 2011-09-15 A (+2191d) |  | 0% → 100% | 41d → none |  |
| 5 | Request Permits | 2005-09-16 → 2011-09-16 A (+2191d) | 2005-09-16 → 2011-09-16 A (+2191d) |  | 0% → 100% | 41d → none |  |
| 6 | Obtain Permits | 2005-09-19 → 2011-09-19 A (+2191d) | 2005-09-23 → 2011-09-23 A (+2191d) |  | 0% → 100% | 41d → none |  |
| 7 | Get Bids | 2005-09-27 → 2011-09-27 A (+2191d) | 2005-10-03 → 2011-10-05 A (+2193d) | 1w → 1.38w | 0% → 100% | 41d → none | was named Obtain Bids |
| 8 | Select Subcontractors | 2005-10-04 → 2011-10-05 A (+2192d) | 2005-10-10 → 2011-10-12 A (+2193d) |  | 0% → 100% | 41d → none | constraint start no earlier than 2002-07-29 → none |
| 9 | Complete Planning Phase | 2005-10-10 → 2011-10-12 A (+2193d) | 2005-10-10 → 2011-10-12 A (+2193d) |  | 0% → 100% | 41d → none |  |
| 10 | **Build Structure** | 2005-08-22 → 2011-08-22 A (+2191d) | 2005-10-19 → 2011-10-04 A (+2176d) | 43d → 32d | 0% → 100% | 0d → none |  |
| 11 | **Build Foundation** | 2005-08-22 → 2011-08-22 A (+2191d) | 2005-09-02 → 2011-08-30 A (+2188d) | 10d → 6.5d | 0% → 100% | 0d → none |  |
| 12 | Dig Foundation | 2005-08-22 → 2011-08-22 A (+2191d) | 2005-08-24 → 2011-08-24 A (+2191d) |  | 0% → 100% | 0d → none |  |
| 13 | Smooth Foundation | 2005-08-25 → 2011-08-25 A (+2191d) | 2005-08-25 → 2011-08-29 A (+2195d) | 1d → 2.5d | 0% → 100% | 0d → none |  |
| 14 | Pour Foundation | 2005-08-26 → 2011-08-29 A (+2194d) | 2005-09-02 → 2011-08-30 A (+2188d) | 6d → 1d | 0% → 100% | 0d → none | resources Laborer → Laborer; Concrete [500%] |
| 15 | **Construct Frame** | 2005-09-07 → 2011-08-22 A (+2175d) | 2005-09-20 → 2011-09-02 A (+2173d) |  | 0% → 100% | 0d → none |  |
| 16 | Frame House | 2005-09-07 → 2011-08-22 A (+2175d) | 2005-09-14 → 2011-08-29 A (+2175d) |  | 0% → 100% | 0d → none |  |
| 17 | Frame Garage | 2005-09-16 → 2011-08-31 A (+2175d) | 2005-09-20 → 2011-09-02 A (+2173d) |  | 0% → 100% | 0d → none |  |
| 18 | Install Roof | 2005-09-21 → 2011-09-05 A (+2175d) | 2005-09-27 → 2011-09-09 A (+2173d) |  | 0% → 100% | 0d → none | resources Roofer [200%] → Roofer [200%]; Roofing Materials [2.5%] |
| 19 | Install Doors | 2005-09-28 → 2011-09-12 A (+2175d) | 2005-09-29 → 2011-09-14 A (+2176d) | 2d → 3d | 0% → 100% | 0d → none | resources Laborer [200%] → Laborer [200%]; Doors [41.7%] |
| 20 | Install Windows | 2005-10-03 → 2011-09-19 A (+2177d) | 2005-10-07 → 2011-09-22 A (+2176d) | 5d → 4d | 0% → 100% | 0d → none | resources Laborer [200%] → Laborer [200%]; Windows [75%] |
| 21 | Install Siding | 2005-10-10 → 2011-09-23 A (+2174d) | 2005-10-14 → 2011-09-29 A (+2176d) |  | 0% → 100% | 0d → none | resources Laborer [200%] → Laborer [200%]; Siding Materials [2.5%] |
| 22 | Build Deck | 2005-10-17 → 2011-09-30 A (+2174d) | 2005-10-19 → 2011-10-04 A (+2176d) |  | 0% → 100% | 0d → none |  |
| 23 | **Build Infrastructure** | 2005-10-20 → 2011-10-05 (+2176d) | 2005-12-06 → 2012-07-05 (+2403d) | 34d → 196.56d |  |  |  |
| 24 | Initial Plumbing | 2005-10-20 → 2011-10-05 (+2176d) | 2005-10-28 → 2011-10-13 (+2176d) |  |  |  |  |
| 25 | Initial Electricity | 2005-10-20 → 2011-10-05 (+2176d) | 2005-11-02 → 2011-10-18 (+2176d) |  |  |  |  |
| 26 | Security System | 2005-11-03 → 2011-10-19 (+2176d) | 2005-11-03 → 2011-10-19 (+2176d) |  |  |  |  |
| 27 | Install Cable | 2005-11-03 → 2011-10-19 (+2176d) | 2005-11-03 → 2011-10-19 (+2176d) |  |  |  |  |
| 28 | Run Phone Lines | 2005-11-03 → 2011-10-19 (+2176d) | 2005-11-03 → 2011-10-19 (+2176d) |  |  |  |  |
| 29 | Insulation | 2005-11-04 → 2011-10-20 (+2176d) | 2005-11-07 → 2012-04-17 (+2353d) | 2d → 129d |  |  | resources Laborer [300%] → Laborer [300%]; Insulation [0.1%] |
| 30 | Drywall | 2005-11-08 → 2012-04-18 (+2353d) | 2005-11-11 → 2012-05-08 (+2370d) | 4d → 14.62d |  |  | resources Laborer [200%] → Laborer [200%]; Drywall [0.9%] |
| 31 | Painting | 2005-11-14 → 2012-05-08 (+2367d) | 2005-11-15 → 2012-05-11 (+2369d) | 2d → 3d |  |  | resources Painter [400%] → Painter; Paint [4.2%] |
| 32 | Flooring | 2005-11-18 → 2012-05-15 (+2370d) | 2005-11-24 → 2012-06-21 (+2401d) | 1w → 5.38w |  |  | resources Laborer [200%] → Laborer [200%]; Tile [0.5%] |
| 33 | Final Plumbing | 2005-11-25 → 2012-06-21 (+2400d) | 2005-11-28 → 2012-06-26 (+2402d) | 2d → 3.12d |  |  | resources Plumber → Plumber; Plumbing Supplies [4%] |
| 34 | Final Electric | 2005-11-25 → 2012-06-21 (+2400d) | 2005-11-25 → 2012-06-26 (+2405d) | 1d → 3.06d |  |  | resources Electrician [200%] → Electrician [200%]; Light Fixtures [4.1%] |
| 35 | Cabinets | 2005-11-28 → 2012-06-26 (+2402d) | 2005-11-29 → 2012-06-28 (+2403d) |  |  |  |  |
| 36 | Wood Trim | 2005-11-30 → 2012-06-28 (+2402d) | 2005-12-02 → 2012-07-03 (+2405d) |  |  |  |  |
| 37 | Carpeting | 2005-12-05 → 2012-07-03 (+2402d) | 2005-12-06 → 2012-07-05 (+2403d) |  |  |  | resources Carpet Layer [200%] → Carpet Layer; Carpet [6.2%] |
